# MuCap Run11

Schedule from GanttProject, 2007-08-01 to 2007-10-28.
MuCap collaboration

## Calendars

- Project calendar: Mon-Sun working.

## Resources

| Resource |
| --- |
| FG |
| BK |
| BL |
| CP |
| CHUPS |
| KL |
| MH |
| PK |
| PW |
| SK |
| VT |
| GP |
| TG |

## Schedule

| ID | WBS | Task | Duration | Start | Finish | Predecessors | Resources |
| --- | --- | --- | --- | --- | --- | --- | --- |
| 1 | 1 | **beam time** | 89d | 2007-08-01 | 2007-10-28 |  |  |
| 2 | 1.1 | **measurements** | 89d | 2007-08-01 | 2007-10-28 |  |  |
| 3 | 1.1.1 | **setup in piE3** | 6d | 2007-08-16 | 2007-08-21 |  |  |
| 4 | 1.1.1.1 | det/daq setup | 4d | 2007-08-16 | 2007-08-19 |  |  |
| 5 | 1.1.1.2 | beam tuning | 2d | 2007-08-18 | 2007-08-19 |  |  |
| 6 | 1.1.1.3 | TPC setup | 5d | 2007-08-17 | 2007-08-21 |  |  |
| 7 | 1.1.1.4 | CHUPS setup | 2d | 2007-08-16 | 2007-08-17 |  |  |
| 8 | 1.1.2 | **production** | 58d | 2007-08-20 | 2007-10-16 |  |  |
| 9 | 1.1.2.1 | **mu+** | 52d | 2007-08-22 | 2007-10-12 |  |  |
| 10 | 1.1.2.1.1 | 1 | 5d | 2007-08-22 | 2007-08-26 | 6 |  |
| 11 | 1.1.2.1.2 | 2 | 18d | 2007-09-25 | 2007-10-12 | 13 |  |
| 12 | 1.1.2.2 | **mu-** | 47d | 2007-08-31 | 2007-10-16 |  |  |
| 13 | 1.1.2.2.1 | 1 | 25d | 2007-08-31 | 2007-09-24 |  |  |
| 14 | 1.1.2.2.2 | 2 | 4d | 2007-10-13 | 2007-10-16 | 11 |  |
| 15 | 1.1.2.3 | AK3 | 2d | 2007-08-20 | 2007-08-21 | 4 |  |
| 16 | 1.1.3 | **systematics** | 89d | 2007-08-01 | 2007-10-28 |  |  |
| 17 | 1.1.3.1 | H2O/mu+ | 6d | 2007-10-23 | 2007-10-28 | 18 |  |
| 18 | 1.1.3.2 | Ar/mu+ | 6d | 2007-10-17 | 2007-10-22 | 14 |  |
| 19 | 1.1.3.3 | accidentals | 1d | 2007-08-01 | 2007-08-01 |  |  |
| 20 | 1.2 | **no beam** | 46d | 2007-08-27 | 2007-10-11 |  |  |
| 21 | 1.2.1 | 1 | 4d | 2007-08-27 | 2007-08-30 |  |  |
| 22 | 1.2.2 | 2 | 3d | 2007-09-17 | 2007-09-19 |  |  |
| 23 | 1.2.3 | 3 | 4d | 2007-10-08 | 2007-10-11 |  |  |
| 24 | 2 | **detectors** | 2d | 2007-08-01 | 2007-08-02 |  |  |
| 25 | 2.1 | **survey** | 1d | 2007-08-01 | 2007-08-01 |  |  |
| 26 | 2.1.1 | survey? | 1d | 2007-08-01 | 2007-08-01 |  | PW |
| 27 | 2.1.2 | mPC alignment | 1d | 2007-08-01 | 2007-08-01 |  | PK |

| ID | WBS | Task | Duration | Start | Finish | Predecessors | Resources |
| --- | --- | --- | --- | --- | --- | --- | --- |
| 28 | 2.2 | **TPC** | 2d | 2007-08-01 | 2007-08-02 |  |  |
| 29 | 2.2.1 | prep and operation | 1d | 2007-08-01 | 2007-08-01 |  | CP; MH |
| 30 | 2.2.2 | electronics noise | 1d | 2007-08-02 | 2007-08-02 | 29 | GP |
| 31 | 2.3 | **mDet** | 2d | 2007-08-01 | 2007-08-02 |  |  |
| 32 | 2.3.1 | mSC+beam | 1d | 2007-08-02 | 2007-08-02 |  | BK; PW |
| 33 | 2.3.2 | mPC | 1d | 2007-08-01 | 2007-08-01 |  | SK; PK |
| 34 | 2.4 | **eSC** | 1d | 2007-08-01 | 2007-08-01 |  |  |
| 35 | 2.4.1 | check | 1d | 2007-08-01 | 2007-08-01 |  | BK; PW |
| 36 | 2.4.2 | optimize thresholds | 1d | 2007-08-01 | 2007-08-01 |  | BK |
| 37 | 2.5 | **ePC** | 1d | 2007-08-01 | 2007-08-01 |  |  |
| 38 | 2.5.1 | start HV ramping | 1d | 2007-08-01 | 2007-08-01 |  | PW; PK |
| 39 | 2.5.2 | fix electronics, wires | 1d | 2007-08-01 | 2007-08-01 |  | PW; PK |
| 40 | 2.5.3 | optimal threshold, eff, HV | 1d | 2007-08-01 | 2007-08-01 |  | BK |
| 41 | 2.6 | **nDet** | 1d | 2007-08-01 | 2007-08-01 |  |  |
| 42 | 2.6.1 | check | 1d | 2007-08-01 | 2007-08-01 |  | SK; PW |
| 43 | 3 | **Gas system** | 1d | 2007-08-01 | 2007-08-01 |  |  |
| 44 | 3.1 | H2O calibrator | 1d | 2007-08-01 | 2007-08-01 |  | CHUPS |
| 45 | 3.2 | CHUPS+TPC test | 1d | 2007-08-01 | 2007-08-01 |  | CHUPS |
| 46 | 4 | **magnet** | 1d | 2007-08-01 | 2007-08-01 |  |  |
| 47 | 4.1 | mount and check | 1d | 2007-08-01 | 2007-08-01 |  | BL |
| 48 | 5 | **daq+electronics** | 1d | 2007-08-01 | 2007-08-01 |  |  |
| 49 | 5.1 | install WFD | 1d | 2007-08-01 | 2007-08-01 |  | VT; KL |
| 50 | 5.2 | neutron FADC | 1d | 2007-08-01 | 2007-08-01 |  | FG; SK; PW |
| 51 | 5.3 | TPC FADC | 1d | 2007-08-01 | 2007-08-01 |  | FG; PW |
| 52 | 5.4 | TPC trigger | 1d | 2007-08-01 | 2007-08-01 |  | PK |
| 53 | 5.5 | big cats | 1d | 2007-08-01 | 2007-08-01 |  | VT; BK |

| ID | WBS | Task | Duration | Start | Finish | Resources |
| --- | --- | --- | --- | --- | --- | --- |
| 54 | 6 | **AK3** | 1d | 2007-08-01 | 2007-08-01 |  |
| 55 | 6.1 | prepare target | 1d | 2007-08-01 | 2007-08-01 | BK |
| 56 | 6.2 | plan setup | 1d | 2007-08-01 | 2007-08-01 | BK; FG |
| 57 | 7 | **slow control** | 1d | 2007-08-01 | 2007-08-01 |  |
| 58 | 7.1 | mount, improve | 1d | 2007-08-01 | 2007-08-01 | BL |
| 59 | 8 | **analysis** | 1d | 2007-08-01 | 2007-08-01 |  |
| 60 | 8.1 | **online** | 1d | 2007-08-01 | 2007-08-01 |  |
| 61 | 8.1.1 | online spectra | 1d | 2007-08-01 | 2007-08-01 | VT; KL; PW |
| 62 | 8.1.2 | trend plots | 1d | 2007-08-01 | 2007-08-01 | KL; PW |
| 63 | 8.1.3 | document | 1d | 2007-08-01 | 2007-08-01 |  |
| 64 | 8.2 | **offline** | 1d | 2007-08-01 | 2007-08-01 |  |
| 65 | 8.2.1 | big cats | 1d | 2007-08-01 | 2007-08-01 | BK |
| 66 | 8.2.2 | WFDscope | 1d | 2007-08-01 | 2007-08-01 | VT; KL |
